Schedule from MS Project MPX, 2017-09-14 to 2017-09-28, A marks actual dates.

## Schedule

| ID | WBS | Task | Duration | Finish | Predecessors | Complete | Actual start | Text1 |
| --- | --- | --- | --- | --- | --- | --- | --- | --- |
| 1 | 1 | To display the category (Text1) and description (Task2) you will need to manually add them to the columns that are displayed. |  |  |  |  |  |  |
| 3 | 3 | **Project Kick-off** | 1.12d | 2017-09-15 |  | 100% | 2017-09-14 |  |
| 4 | 3.1 | Project Brief | 0.12d | 2017-09-14 |  | 100% | 2017-09-14 | Project Management |
| 5 | 3.2 | Complete Project Schedule | 1d | 2017-09-15 | 4 | 100% | 2017-09-14 | Project Management |
| 6 | 4 | **Copy** | 4.5d | 2017-09-21 |  | 100% | 2017-09-15 |  |
| 7 | 4.1 | Develop Copy | 2d | 2017-09-19 | 5 | 100% | 2017-09-15 | Writing |
| 8 | 4.2 | Marketing Review | 1d | 2017-09-20 | 7 | 100% | 2017-09-19 | Review |
| 9 | 4.3 | Copy Edits | 0.5d | 2017-09-20 | 8 | 100% | 2017-09-20 | Writing |
| 10 | 4.4 | Design | 0.5d | 2017-09-20 | 8 | 100% | 2017-09-20 | Design |
| 11 | 4.5 | Design Edits | 1d | 2017-09-21 | 10 | 100% | 2017-09-20 | Design |
| 12 | 5 | **Proofing** | 4d | 2017-09-26 |  | 100% | 2017-09-20 |  |
| 13 | 5.1 | Proof | 1d | 2017-09-21 | 9, 10 | 100% | 2017-09-20 | Proofing |
| 14 | 5.2 | Digital Review | 0.5d | 2017-09-22 | 13 | 100% | 2017-09-21 | Review |
| 15 | 5.3 | Edits from Digital Review | 0.5d | 2017-09-22 | 14 | 100% | 2017-09-22 | Design |
| 16 | 5.4 | Marketing Final Sign off | 1d | 2017-09-25 | 15 | 100% | 2017-09-22 | Review |
| 17 | 5.5 | Client Final Review | 1d | 2017-09-26 | 16 | 100% | 2017-09-25 | Review |
| 18 | 6 | **Production** | 1.5d | 2017-09-28 |  | 100% | 2017-09-26 |  |
| 19 | 6.1 | Publish posts on social | 0.5d | 2017-09-27 | 17 | 100% | 2017-09-26 | Production |
| 20 | 6.2 | Provide metrics for post(s) | 1d | 2017-09-28 | 19 | 100% | 2017-09-27 | Operations |
